# GERAN2 work plan

Schedule from MS Project, 2001-05-11 to 2004-08-27, A marks actual dates.
3GPP work plan
Vodafone
Tel: +44 1635 676093 / E-mail: jose-luis.carrizo@vodafone.co.uk

## Calendars

- Standard: Mon-Fri 08:00-12:00, 13:00-17:00; Sat-Sun off.

## Resources

| Resource |
| --- |
| TSG GERAN |
| WG GERAN1 |
| WG GERAN2 |
| WG GERAN4 |
| GERAN1 |
| G2 |
| GERAN4/5 |
| GERAN 4/5 |
| GERAN3 |
| CN1 |
| SA1 |
| SA2 |
| TSG RAN |
| TSG CN |
| SA3 |
| GP |
| G4 |
| G5 |
| S1 |
| S2 |
| R2 |
| N1 |
| S3 |
| G1 |
| G2 |
| G3 |

## Schedule

| ID | WBS | Task | Duration | Start | Finish | Predecessors | Complete | Remaining | Baseline start | Baseline finish | Baseline duration | Total slack | Free slack | Constraint | Resources | Work | Actual work | Text6 | Text1 | Text2 | Text3 | Text7 | Text5 | Text8 | Text9 |
| --- | --- | --- | --- | --- | --- | --- | --- | --- | --- | --- | --- | --- | --- | --- | --- | --- | --- | --- | --- | --- | --- | --- | --- | --- | --- |
| 1 | 1 | VERSION 5.0 (14 Mar 2003) | 1d | 2002-01-01 | 2002-01-01 |  |  |  | 2000-01-03 | 2000-01-03 | 1d | 693d |  |  |  |  |  | Rel |  |  |  |  |  |  |  |
| 3 | 3 | **Multiple TBF in A/Gb mode** | 461d | 2002-04-19 A | 2004-01-23 |  | 46% | 247.4d | 2002-04-19 | 2002-06-28 | 51d | 155d |  |  | GP | 8216h | 2108.8h | Rel6 | MULTBF | Gunnar Mildh, Ericsson | gunnar.mildh@era.ericsson.se | TSG |  |  |  |
| 4 | 3.1 | Multiple TBF in A/Gb mode | 356d | 2002-04-19 A | 2003-08-29 |  | 60% | 142.4d | 2002-04-19 | 2002-06-28 | 51d | 155d | 0d | finish no earlier than 2003-08-29 | GP | 2848h | 1708.8h |  | MULTBF-Agbmode | Gunnar Mildh, Ericsson | gunnar.mildh@era.ericsson.se |  |  |  |  |
| 5 | 3.2 | Multiple TBF in A/Gb mode – MS testing | 105d | 2003-09-01 | 2004-01-23 | 4 |  |  |  |  |  | 155d |  | finish no earlier than 2003-11-21 | G4; G5 | 1680h |  |  |  | Ingemar Backlund, Ericsson |  |  | Finish date to be confirmed |  |  |
| 6 | 4 | **Flexible Layer One for GERAN** | 416d | 2002-04-19 A | 2003-11-21 |  | 23% | 320.48d | 2000-01-03 | 2002-06-28 | 650d | 200d |  |  | GP | 10664h | 1491.6h | Rel6 | FLOGER | Benoist Sébire, Nokia | benoist.sebire@nokia.com |  |  |  |  |
| 7 | 4.1 | Realisation of a Flexible Layer One | 311d | 2002-04-19 A | 2003-06-27 |  | 40% | 186.6d | 2000-01-03 | 2002-06-28 | 650d | 200d | 0d | finish no earlier than 2003-06-27 | GP | 2488h | 995.2h |  | FLOGER-Real | Benoist Sébire, Nokia | benoist.sebire@nokia.com |  |  |  |  |
| 8 | 4.2 | Signalling and protocol support for a Flexible Layer One | 190d | 2002-10-07 A | 2003-06-27 |  | 30% | 133d | 2002-04-19 | 2002-06-28 | 51d | 200d | 0d | finish no earlier than 2003-06-27 | G2 | 1520h | 456h |  | FLOGER-SigPro | Benoist Sébire, Nokia | benoist.sebire@nokia.com |  |  |  |  |
| 9 | 4.3 | Security for a Flexible Layer One | 101d | 2003-02-07 A | 2003-06-27 |  | 5% | 95.95d | 2002-04-19 | 2002-06-28 | 51d | 200d | 0d | start no earlier than 2003-02-07 | G2 | 808h | 40.4h |  | FLOGER-SecFLO | Benoist Sébire, Nokia | benoist.sebire@nokia.com |  |  |  |  |
| 10 | 4.4 | GERAN MS Conformance test for the Flexible Layer One | 105d | 2003-06-30 | 2003-11-21 | 7, 8, 9 |  |  | 2002-04-19 | 2002-06-28 | 51d | 200d |  | finish no earlier than 2003-11-21 | G4; G5 | 1680h |  |  | FLOGER-Msconf | Benoist Sébire, Nokia | benoist.sebire@nokia.com |  |  |  |  |
| 11 | 4.5 | GERAN BTS Conformance test for the Flexible Layer One | 105d | 2003-06-30 | 2003-11-21 | 7, 8, 9 |  |  | 2002-04-19 | 2002-06-28 | 51d | 200d |  | finish no earlier than 2003-11-21 | G3 | 840h |  |  | FLOGER-BTSconf | Benoist Sébire, Nokia | benoist.sebire@nokia.com |  |  |  |  |
| 12 | 6 | **Multimedia Broadcast and Multicast Service** | 661d | 2001-05-11 A | 2003-11-21 |  | 34% | 434.69d | 2001-05-11 | 2003-09-30 | 623d | 200d |  |  |  | 18094.2h | 6871.65h | Rel6 | MBMS |  |  |  |  | Michael C. |  |
| 13 | 6.1 | Stage 1 | 226.78d | 2001-05-11 A | 2002-03-25 A |  | 100% |  | 2001-05-11 | 2002-04-01 | 232d |  |  | start no earlier than 2001-05-11 | S1 | 1814.24h | 1814.24h |  |  |  |  |  |  | Micheal C | 11003 |
| 14 | 6.2 | **Stage 2** | 445d | 2001-09-24 A | 2003-06-06 |  | 67% | 147.44d | 2001-08-31 | 2002-09-20 | 276d | 320d |  |  | S2 | 7160h | 4302.65h |  |  |  |  | TSG |  |  |  |
| 15 | 6.2.1 | TR on Architectural Study | 240d | 2001-09-24 A | 2002-08-23 A |  | 100% |  |  |  |  |  |  | finish no earlier than 2002-08-23 | S2 | 1920h | 1920h |  |  |  |  |  |  |  |  |
| 16 | 6.2.2 | Stage 2 Specification Work | 210d | 2002-08-19 A | 2003-06-06 |  | 29% | 149.1d |  |  |  | 320d |  | finish no earlier than 2003-06-06 | S2 | 1680h | 487.2h |  |  |  |  |  |  |  |  |
| 17 | 6.3 | Introduction of MBMS in RAN | 379d | 2002-01-01 A | 2003-06-13 |  | 7% | 352.47d | 2002-01-01 | 2003-09-30 | 456d | 315d |  | finish no earlier than 2003-06-13 | R2 | 3032h | 212.24h |  |  | Dimitris Koulakiotis, Nokia |  | TSG |  |  | 2481 |
| 18 | 6.4 | Support of the MBMS in CN protocols | 321d | 2002-06-18 A | 2003-09-09 |  | 2% | 314.68d |  |  |  | 253d |  | finish no earlier than 2003-09-09 | N1 | 2568h | 50.53h |  |  |  |  | TSG |  |  |  |
| 19 | 6.5 | Security Aspects of Multimedia Broadcast/Multicast Service (MBMS) | 175d | 2002-07-01 A | 2003-02-28 |  | 20% | 140d |  |  |  | 390d |  | finish no earlier than 2003-02-28 | S3 | 1400h | 280h |  | MBMS | Escott, Adrian, Hutchison 3G UK | adrian.escott@hutchison3g.com | TSG |  |  |  |
| 20 | 6.6 | Support of MBMS in GERAN | 265d | 2002-11-18 A | 2003-11-21 |  | 10% | 238.5d |  |  |  | 200d |  | finish no earlier than 2003-11-21 | GP | 2120h | 212h | Rel6 | MBMS-GERAN | José Luis Carrizo Martínez, Vodafone | jose-luis.carrizo@gb.vodafone.co.uk | TSG |  |  |  |
| 21 | 7 | **Seamless support of streaming services in A/Gb mode** | 371d | 2002-08-30 A | 2004-01-30 |  | 33% | 248.12d |  |  |  | 150d |  |  | GP | 10384h | 3147.84h | Rel6 | SSStrea | José Luis Carrizo Martínez, Vodafone | jose-luis.carrizo@gb.vodafone.co.uk |  |  |  |  |
| 22 | 7.1 | Identification of requirements for streaming | 216d | 2002-08-30 A | 2003-06-27 |  | 50% | 108d |  |  |  | 305d |  | finish no earlier than 2003-06-27 | GP | 1728h | 864h |  |  | José Luis Carrizo Martínez, Vodafone | jose-luis.carrizo@gb.vodafone.co.uk |  |  |  |  |
| 23 | 7.2 | Performance study of cell change mechanisms | 216d | 2002-08-30 A | 2003-06-27 |  | 60% | 86.4d |  |  |  | 305d |  | finish no earlier than 2003-06-27 | GP | 1728h | 1036.8h |  |  | José Luis Carrizo Martínez, Vodafone | jose-luis.carrizo@gb.vodafone.co.uk |  |  |  |  |
| 24 | 7.3 | Reduction of service interruption times and packet loss during mobility procedures | 165d | 2003-01-13 A | 2003-08-29 | 22, 23 | 20% | 132d |  |  |  | 150d | 0d | finish no earlier than 2003-08-29 | GP | 1320h | 264h |  |  | José Luis Carrizo Martínez, Vodafone | jose-luis.carrizo@gb.vodafone.co.uk |  |  |  |  |
| 25 | 7.5 | MS conformance testing | 110d | 2003-09-01 | 2004-01-30 | 24 |  |  |  |  |  | 150d |  | finish no earlier than 2004-01-30 | G4; G5 | 1760h |  |  |  |  |  |  |  |  |  |
| 26 | 7.6 | BTS conformance testing | 110d | 2003-09-01 | 2004-01-30 | 24 |  |  |  |  |  | 150d |  | finish no earlier than 2004-01-30 | G3 | 880h |  |  |  |  |  |  |  |  |  |

Notes:
- 3: Text4: Cingular, Ericsson, Motorola, Nortel Networks, Telia, Vodafone Group
- 4: Text4: Cingular, Ericsson, Motorola, Nortel Networks, Telia, Vodafone Group
- 5: Text4: Cingular, Ericsson, Motorola, Nortel Networks, Telia, Vodafone Group
- 6: Nokia, Ericsson, Siemens, Telia / Text4: Nokia, Ericsson, Siemens, Telia
- 7: Text4: Nokia, Ericsson, Siemens, Telia
- 8: Text4: Nokia, Ericsson, Siemens, Telia
- 9: Text4: Nokia, Ericsson, Siemens, Telia
- 10: Text4: Nokia, Ericsson, Siemens, Telia
- 11: Text4: Nokia, Ericsson, Siemens, Telia
- 12: Title renamed at SA#13
- 13: This may or may not be a separate stage 1. In the meantime, CRs are proposed for 22.101
- 19: WID approved SA#17
- 20: Text4: Ericsson, Nokia, Siemens, Vodafone
- 21: Text4: Ericsson, Nortel Networks, Siemens, T-Mobile, Vodafone
- 22: Text4: Ericsson, Nortel Networks, Siemens, T-Mobile, Vodafone
- 23: Text4: Ericsson, Nortel Networks, Siemens, T-Mobile, Vodafone
- 24: Text4: Ericsson, Nortel Networks, Siemens, T-Mobile, Vodafone

| ID | WBS | Task | Duration | Start | Finish | Predecessors | Complete | Remaining | Total slack | Free slack | Constraint | Resources | Work | Actual work | Text1 | Text2 | Text3 |
| --- | --- | --- | --- | --- | --- | --- | --- | --- | --- | --- | --- | --- | --- | --- | --- | --- | --- |
| 27 | 8 | **Uplink TDOA Location Determination for GSM/GPRS** | 261d? | 2002-11-22 A | 2003-11-21 |  | 12% | 229.92d? | 200d |  |  | GP | 6272h | 746.89h | UTDOA | Bob Gross, TruePosition, Inc. | rlgross@trueposition.com |
| 28 | 6.1 | **Uplink TDOA Location Determination for GSM/GPRS** | 261d? | 2002-11-22 A | 2003-11-21 |  | 12% | 229.92d? | 200d |  |  | GP | 4184h | 498.25h | UTDOA |  |  |
| 29 | 6.1.1 | Addition of U-TDOA in the CS domain | 156d? | 2002-11-22 A | 2003-06-27 |  | 20% | 124.8d? | 305d |  | finish no earlier than 2003-06-27 | GP | 1248h | 249.6h | UTDOA-CS |  |  |
| 30 | 6.1.2 | Addition of U-TDOA in the PS domain | 106d? | 2003-06-27 | 2003-11-21 |  |  |  | 200d |  | start no earlier than 2003-06-27 | GP | 848h |  | UTDOA-PS |  |  |
| 31 | 10 | **Support of Conversational Services in A/Gb Mode via the PS Domain** | 406d? | 2003-02-07 A | 2004-08-27 |  | 1% | 401.43d? | 0d |  |  |  | 7328h | 82.4h | SCSAGB | David Bladsjö, Ericsson | david.bladsjo@era.ericsson.se |
| 32 | 10.1 | Technical Report | 206d? | 2003-02-07 A | 2003-11-21 |  | 5% | 195.7d? | 90d | 0d | finish no earlier than 2003-11-21 | GP | 1648h | 82.4h | SCSAGB-TR | David Bladsjö, Ericsson | david.bladsjo@era.ericsson.se |
| 33 | 10.2 | Stage 2 | 110d? | 2003-11-24 | 2004-04-23 | 32 |  |  | 90d |  | finish no earlier than 2004-04-23 | GP | 880h |  | SCSAGB-Stage2 | David Bladsjö, Ericsson | david.bladsjo@era.ericsson.se |
| 34 | 10.7 | Radio Channel Support | 150d? | 2004-02-02 | 2004-08-27 |  |  |  | 0d |  | finish no earlier than 2004-08-27 | GP | 1200h |  | SCSAGB-RCS | David Bladsjö, Ericsson | david.bladsjo@era.ericsson.se |
| 35 | 10.4 | Definition of Radio Resource Management Functionality | 150d? | 2004-02-02 | 2004-08-27 |  |  |  | 0d |  | finish no earlier than 2004-08-27 | GP | 1200h |  | SCSAGB-RRM | David Bladsjö, Ericsson | david.bladsjo@era.ericsson.se |
| 36 | 10.8 | PS Handover | 150d? | 2004-02-02 | 2004-08-27 |  |  |  | 0d |  | finish no earlier than 2004-08-27 | GP | 1200h |  | SCSAGB-PSH | David Bladsjö, Ericsson | david.bladsjo@era.ericsson.se |
| 37 | 10.5 | Modifications to FLO | 150d? | 2004-02-02 | 2004-08-27 |  |  |  | 0d |  | finish no earlier than 2004-08-27 | GP | 1200h |  | SCSAGB-FLO | David Bladsjö, Ericsson | david.bladsjo@era.ericsson.se |

Notes:
- 27: Text4: Cingular Wireless, AWS, SBC Technology Resources, Motorola, TruePosition / Text5: CLARIFY: In the 3GPP work plan (Jan 2003) it appear as a Building Block of the feature "Location Services enhancements 2"
- 31: Text4: Alcatel, Cingular Wireless, Ericsson, Nortel Networks, Siemens, T-Mobile, Telecom Italia Mobile, Vodafone Group Plc
- 32: Text4: Alcatel, Cingular Wireless, Ericsson, Nortel Networks, Siemens, T-Mobile, Telecom Italia Mobile, Vodafone Group Plc
- 33: Text4: Alcatel, Cingular Wireless, Ericsson, Nortel Networks, Siemens, T-Mobile, Telecom Italia Mobile, Vodafone Group Plc
- 34: Text4: Alcatel, Cingular Wireless, Ericsson, Nortel Networks, Siemens, T-Mobile, Telecom Italia Mobile, Vodafone Group Plc
- 35: Text4: Alcatel, Cingular Wireless, Ericsson, Nortel Networks, Siemens, T-Mobile, Telecom Italia Mobile, Vodafone Group Plc
- 36: Text4: Alcatel, Cingular Wireless, Ericsson, Nortel Networks, Siemens, T-Mobile, Telecom Italia Mobile, Vodafone Group Plc
- 37: Text4: Alcatel, Cingular Wireless, Ericsson, Nortel Networks, Siemens, T-Mobile, Telecom Italia Mobile, Vodafone Group Plc
